# pattomolf

Schedule from MS Project MPX, 1998-03-19 to 1998-07-22.

## Calendars

- Standard: Mon-Fri 8.00-12.00, 13.00-17.00; Sat-Sun off.

## Schedule

| ID | WBS | Task | Duration | Start | Finish | Predecessors | Total slack | Free slack | Constraint |
| --- | --- | --- | --- | --- | --- | --- | --- | --- | --- |
| 1 | 1 | **PATTO DI MOLFETTA** | 90g | 1998-03-19 | 1998-07-22 |  | 0g |  | il più presto possibile |
| 2 | 1.1 | Protocollo sulla sicurezza | 2g | 1998-04-20 | 1998-04-21 |  | 66g |  | iniziare non prima del 1998-04-20 |
| 3 | 1.2 | Protocollo sul lavoro e relazioni industriali | 1g | 1998-04-07 | 1998-04-07 |  | 76g |  | iniziare non prima del 1998-04-07 |
| 4 | 1.3 | **Definizione del Soggetto Responsabile** | 8g | 1998-03-23 | 1998-04-01 |  | 80g |  | il più presto possibile |
| 5 | 1.3.1 | Ipotesi di composizione e forma giuridica | 8g | 1998-03-23 | 1998-04-01 |  | 80g |  | iniziare non prima del 1998-03-23 |
| 6 | 1.3.2 | Bozza di Statuto | 8g | 1998-03-23 | 1998-04-01 |  | 80g |  | iniziare non prima del 1998-03-23 |
| 7 | 1.3.3 | Atti costitutivi | 8g | 1998-03-23 | 1998-04-01 |  | 80g |  | iniziare non prima del 1998-03-23 |
| 8 | 1.3.4 | Organismi statutari | 8g | 1998-03-23 | 1998-04-01 |  | 80g |  | iniziare non prima del 1998-03-23 |
| 9 | 1.3.5 | Funzioni e resposnsabilità | 8g | 1998-03-23 | 1998-04-01 |  | 80g |  | iniziare non prima del 1998-03-23 |
| 10 | 1.4 | Costituzione del comitato di Verifica e Controllo | 1g | 1998-04-15 | 1998-04-15 |  | 70g |  | iniziare non prima del 1998-04-15 |
| 11 | 1.5 | **Istruttoria tecnica progetti** | 68g | 1998-03-19 | 1998-06-22 |  | 22g |  | il più presto possibile |
| 12 | 1.5.1 | Preparazione schede 488 | 3g | 1998-03-19 | 1998-03-23 |  | 86g | 4g | iniziare non prima del 1998-03-19 |
| 13 | 1.5.2 | **Incontri imprenditori (comunic. date ed elenchi)** | 7g | 1998-03-30 | 1998-04-07 | 12 | 76g |  | il più presto possibile |
| 14 | 1.5.2.1 | Incontro informativo Bisceglie | 1g | 1998-04-06 | 1998-04-06 |  | 77g |  | iniziare non prima del 1998-04-06 |
| 15 | 1.5.2.2 | Incontro informativo Bitonto | 1g | 1998-04-01 | 1998-04-01 |  | 80g |  | iniziare non prima del 1998-04-01 |
| 16 | 1.5.2.3 | Incontro informativo Giovinazzo | 1g | 1998-04-07 | 1998-04-07 |  | 76g |  | iniziare non prima del 1998-04-07 |
| 17 | 1.5.2.4 | Incontro informativo Molfetta | 1g | 1998-03-30 | 1998-03-30 |  | 82g |  | iniziare non prima del 1998-03-30 |
| 18 | 1.5.2.5 | Incontro informativo Palo del Colle | 1g | 1998-04-03 | 1998-04-03 |  | 78g |  | iniziare non prima del 1998-04-03 |
| 19 | 1.5.2.6 | Incontro informativo Ruvo di Puglia | 1g | 1998-03-31 | 1998-03-31 |  | 81g |  | iniziare non prima del 1998-03-31 |
| 20 | 1.5.2.7 | Incontro informativo Terlizzi | 1g | 1998-04-02 | 1998-04-02 |  | 79g |  | iniziare non prima del 1998-04-02 |
| 21 | 1.5.3 | Raccolta delle schede progettuali in base alla 488 | 2g | 1998-04-28 | 1998-04-29 |  | 0g |  | iniziare non prima del 1998-04-28 |
| 22 | 1.5.4 | Esame di congruità singoli progetti/obiettivi del Patto | 30g | 1998-04-30 | 1998-06-10 | 21 | 0g |  | il più presto possibile |
| 23 | 1.5.5 | Eliggibilità dei progetti ad altre fonti di finanziamento | 2g | 1998-06-11 | 1998-06-12 | 22 | 22g | 0g | il più presto possibile |
| 24 | 1.5.6 | Ammissione dei progetti al Patto | 2g | 1998-06-15 | 1998-06-16 | 23 | 22g | 0g | il più presto possibile |
| 25 | 1.5.7 | Documento di analisi progettualità proposta | 3g | 1998-06-17 | 1998-06-19 | 24 | 22g | 0g | il più presto possibile |
| 26 | 1.5.8 | Conferenza di servizio quadro progettuale | 1g | 1998-06-22 | 1998-06-22 | 25 | 22g |  | il più presto possibile |

Notes:
- 26: Conferenza nella quale verranno illustrate l'incidenza percentuale dei progetti proposti in base alla 488. Valutazione congruità ripetto agli obiettivi. Eventuali criteri ulteriori di selezione.

| ID | WBS | Task | Duration | Start | Finish | Predecessors | Total slack | Free slack | Constraint |
| --- | --- | --- | --- | --- | --- | --- | --- | --- | --- |
| 27 | 1.6 | **Programma Operativo di Sviluppo Locale** | 11g | 1998-05-01 | 1998-05-15 |  | 48g |  | il più presto possibile |
| 28 | 1.6.1 | Definizione del programma, misure e progetti collegati | 5g | 1998-05-01 | 1998-05-07 |  | 48g | 0g | iniziare non prima del 1998-05-01 |
| 29 | 1.6.2 | Piano temporale di attuazione | 2g | 1998-05-08 | 1998-05-11 | 28 | 48g | 0g | il più presto possibile |
| 30 | 1.6.3 | Piano finanziario di sviluppo | 2g | 1998-05-12 | 1998-05-13 | 29 | 48g | 0g | il più presto possibile |
| 31 | 1.6.4 | Individuazione di altri possibili cofinanziamenti | 2g | 1998-05-14 | 1998-05-15 | 30 | 48g |  | il più presto possibile |
| 32 | 1.7 | Individuazione banca per istruttoria | 2g | 1998-04-15 | 1998-04-16 |  | 39g |  | iniziare non prima del 1998-04-15 |
| 33 | 1.8 | Istruttoria delle singole iniziative da parte della Banca | 30g | 1998-06-11 | 1998-07-22 | 32, 22 | 0g |  | iniziare non prima del 1998-05-01 |
| 34 | 1.9 | **Infrastrutture funzionali ai progetti** | 16g | 1998-04-15 | 1998-05-06 |  | 45g |  | il più presto possibile |
| 35 | 1.9.1 | Selezione delle infrastrutture di interesse collettivo | 2g | 1998-04-15 | 1998-04-16 |  | 45g | 0g | iniziare non prima del 1998-04-15 |
| 36 | 1.9.2 | individuazione di altri Fondi di finanziamento | 2g | 1998-04-17 | 1998-04-20 | 35 | 45g | 0g | il più presto possibile |
| 37 | 1.9.3 | Raccolta protocolli, atti e delibere | 7g | 1998-04-21 | 1998-04-29 | 36 | 45g | 0g | il più presto possibile |
| 38 | 1.9.4 | piano finanziario e di attuazione | 5g | 1998-04-30 | 1998-05-06 | 37 | 45g | 0g | il più presto possibile |
| 39 | 1.10 | Documento finale del Patto Territoriale | 10g | 1998-05-07 | 1998-05-20 | 38 | 45g |  | il più presto possibile |

Notes:
- 31: Accertamento della disponibilità di risorse finanziarie a valere anche su altri fondi oltre quelli del CIPE
- 37: Raccolta ed organizzazione di tutti gli atti e le deliberazioni necessarie per la realizzazione degli interventi
